# Radio Ad #1

Schedule from MS Project, 2004-07-12 to 2004-07-14, costs in $.

## Calendars

- Standard: Mon-Fri 08:00-12:00, 13:00-17:00; Sat-Sun off.

## Resources

| Resource | Group | Rate | Cost per use |
| --- | --- | --- | --- |
| Mojave Advertising | Advertising | 250 |  |
| Nina Harris | Marketing | 25 |  |
| Mary Simpson | Marketing | 25 |  |
| Willy Wong | Marketing | 25 |  |
| SF Couriers | Delivery |  | 30 |

## Schedule

| ID | WBS | Task | Duration | Start | Finish | Predecessors | Total slack | Resources | Work | Cost |
| --- | --- | --- | --- | --- | --- | --- | --- | --- | --- | --- |
| 1 | 1 | **Radio Advertising** | 2.88d | 2004-07-12 08:00 | 2004-07-14 16:00 |  | 0d |  | 38h | 3,205 |
| 2 | 1.1 | List points to be covered | 4h | 2004-07-12 08:00 | 2004-07-12 12:00 |  | 0d | Mary Simpson; Nina Harris | 8h | 200 |
| 3 | 1.2 | Write script | 8h | 2004-07-12 13:00 | 2004-07-13 12:00 | 2 | 0d | Mary Simpson; Nina Harris | 16h | 400 |
| 4 | 1.3 | Do voiceovers | 4h | 2004-07-13 13:00 | 2004-07-13 17:00 | 3 | 0d | Mojave Advertising | 4h | 1,000 |
| 5 | 1.4 | Edit sound and music | 6h | 2004-07-14 08:00 | 2004-07-14 15:00 | 4 | 0d | Mojave Advertising | 6h | 1,500 |
| 6 | 1.5 | Book ad space | 3h | 2004-07-12 08:00 | 2004-07-12 11:00 |  | 2.5d | Willy Wong | 3h | 75 |
| 7 | 1.6 | Deliver tape | 1h | 2004-07-14 15:00 | 2004-07-14 16:00 | 5 | 0d | SF Couriers | 1h | 30 |
